# Modelo Projeto (com a parte Gerenciamento)

Schedule from MS Project, 2022-08-01 to 2022-11-30.
cimatec

## Calendars

- Padrão: Mon-Fri 09:00-12:00, 13:00-18:00; Sat-Sun off.

## Resources

| Resource | Group | Unit | Rate |
| --- | --- | --- | --- |
| Erick Matos | RH |  |  |
| Lucas Sena | Material | Und | 475 |
| Serviço de Registro | Serviços | Und |  |
| Eduarda Almeida | RH |  |  |
| Hospedagem de Site | TIC | Und |  |
| Davi Dantas Sampaio | EX |  |  |
| Rodrigo Miranda | EX |  |  |
| Thiago Menezes |  |  |  |
| Placa Fotovoltaica | Material | Und | 950 |
| String Box | Material | Und | 400 |
| Conectores | Material | Und | 15 |
| Cabos | Material | Metro | 3.2 |
| Inversor | Material | Und | 7500 |
| Estrutura de Fixação | Material | Und | 600 |

## Schedule

| ID | WBS | Task | Type | Duration | Start | Finish | Predecessors | Total slack | Free slack |
| --- | --- | --- | --- | --- | --- | --- | --- | --- | --- |
| 1 | 1 | **Subestação Didática** |  | 88d | 2022-08-01 | 2022-11-30 |  | 0d |  |
| 2 | 1.1 | **Relatórios descritivos de Manutenção da Subestação** |  | 68d | 2022-08-01 | 2022-11-02 |  | 17d |  |
| 3 | 1.1.1 | **Plano de manutenção da subestação (Procedimento de Operação Padrão)** |  | 7d | 2022-08-01 | 2022-08-09 |  | 17d | 0d |
| 4 | 1.1.1.1 | Confeccionar Plano Geral da Subestação |  | 7d | 2022-08-01 | 2022-08-09 |  | 17d | 0d |
| 5 | 1.1.1.2 | Plano de Manutenção da substação | milestone | 0d | 2022-08-09 | 2022-08-09 | 4 | 17d |  |
| 6 | 1.1.2 | **Levantamento de normas técnicas referentes ao projeto** |  | 7d | 2022-08-01 | 2022-08-09 |  | 81d |  |
| 7 | 1.1.2.1 | Selecionar tópicos referentes a subestação |  | 7d | 2022-08-01 | 2022-08-09 |  | 81d | 0d |
| 8 | 1.1.2.2 | Referência das normas técnicas | milestone | 0d | 2022-08-09 | 2022-08-09 | 7 | 81d |  |
| 9 | 1.1.3 | **Listamento de materiais para manutenção** |  | 6d | 2022-08-01 | 2022-08-08 |  | 82d |  |
| 10 | 1.1.3.1 | Levantar os EPI's para Subestação |  | 3d | 2022-08-01 | 2022-08-03 |  | 82d | 0d |
| 11 | 1.1.3.2 | Levantar equipamentos de medição para Subestação |  | 3d | 2022-08-04 | 2022-08-08 | 10 | 82d | 0d |
| 12 | 1.1.3.3 | Materiais para a manutenção | milestone | 0d | 2022-08-08 | 2022-08-08 | 11 | 82d |  |
| 13 | 1.1.4 | **Atividade de manutenção para Chave Seccionadora** |  | 24d | 2022-08-10 | 2022-09-12 |  | 17d | 0d |
| 14 | 1.1.4.1 | Descrever verificações gerais do equipameto para Subestação |  | 3d | 2022-08-10 | 2022-08-12 | 3 | 17d | 0d |
| 15 | 1.1.4.2 | Descrever teste de resistência de contato para Subestação |  | 3d | 2022-08-15 | 2022-08-17 | 14 | 17d | 0d |
| 16 | 1.1.4.3 | Descrever teste de tensão aplicada para Subestação |  | 3d | 2022-08-18 | 2022-08-22 | 15 | 17d | 0d |
| 17 | 1.1.4.4 | Descrever teste de oscilografia Subestação |  | 3d | 2022-08-23 | 2022-08-25 | 16 | 17d | 0d |
| 18 | 1.1.4.5 | Descrever teste funcionais da Subestação |  | 3d | 2022-08-26 | 2022-08-30 | 17 | 17d | 0d |
| 19 | 1.1.4.6 | Descrever teste de desconexão mecânica do comando da parte ativa da Subestação |  | 3d | 2022-08-31 | 2022-09-02 | 18 | 17d | 0d |
| 20 | 1.1.4.7 | Descrever teste de conexão mecânica do comando da parte ativa da Subestação |  | 3d | 2022-09-05 | 2022-09-07 | 19 | 17d | 0d |
| 21 | 1.1.4.8 | Descrever teste da parte ativa da Subestação |  | 3d | 2022-09-08 | 2022-09-12 | 20 | 17d |  |
| 22 | 1.1.4.9 | Manutenção para chave Seccionadora | milestone | 0d | 2022-09-07 | 2022-09-07 | 20 | 20d |  |
| 23 | 1.1.5 | **Procedimentos de manutenção do Para-Raios** |  | 3d | 2022-08-10 | 2022-08-12 |  | 78d |  |
| 24 | 1.1.5.1 | Descrever verificações gerais do equipameto para Subestação |  | 3d | 2022-08-10 | 2022-08-12 | 3 | 78d | 0d |
| 25 | 1.1.5.2 | Manutenção de para-raios | milestone | 0d | 2022-08-12 | 2022-08-12 | 24 | 78d |  |

| ID | WBS | Task | Type | Duration | Start | Finish | Predecessors | Total slack | Free slack |
| --- | --- | --- | --- | --- | --- | --- | --- | --- | --- |
| 26 | 1.1.6 | **Procedimentos de manutenção do Barramento** |  | 12d | 2022-08-10 | 2022-08-25 |  | 69d |  |
| 27 | 1.1.6.1 | Descrever verificações gerais do equipameto para Subestação |  | 3d | 2022-08-10 | 2022-08-12 | 3 | 69d | 0d |
| 28 | 1.1.6.2 | Descrever teste de resistência de isolamento da Subestação |  | 3d | 2022-08-15 | 2022-08-17 | 27 | 69d | 0d |
| 29 | 1.1.6.3 | Descrever teste de tensão aplicada da Subestação |  | 3d | 2022-08-18 | 2022-08-22 | 28 | 69d | 0d |
| 30 | 1.1.6.4 | Descrever teste de oscilografia da Subestação |  | 3d | 2022-08-23 | 2022-08-25 | 29 | 69d | 0d |
| 31 | 1.1.6.5 | Manutenção do barramento | milestone | 0d | 2022-08-25 | 2022-08-25 | 30 | 69d |  |
| 32 | 1.1.7 | **Descrever procedimentos de manutenção do Transformador de Corrente (TC)** |  | 12d | 2022-09-13 | 2022-09-28 |  | 17d | 0d |
| 33 | 1.1.7.1 | Descrever verificações gerais do equipameto para Subestação |  | 3d | 2022-09-13 | 2022-09-15 | 13 | 17d | 0d |
| 34 | 1.1.7.2 | Descrever teste de resistência de isolamento da Subestação |  | 3d | 2022-09-16 | 2022-09-20 | 33 | 17d | 0d |
| 35 | 1.1.7.3 | Descrever teste de relação de transformação da Subestação |  | 3d | 2022-09-21 | 2022-09-23 | 34 | 17d | 0d |
| 36 | 1.1.7.4 | Descrever teste de resistência ôhmica dos enrolamentos da Subestação |  | 3d | 2022-09-26 | 2022-09-28 | 35 | 17d | 0d |
| 37 | 1.1.7.5 | Procedimento de manutenção do Transformador de Corrente | milestone | 0d | 2022-09-28 | 2022-09-28 | 36 | 17d |  |
| 38 | 1.1.8 | **Descrever procedimentos de manutenção do Transformador de Potencial (TP)** |  | 12d | 2022-09-13 | 2022-09-28 |  | 45d |  |
| 39 | 1.1.8.1 | Descrever verificações gerais do equipameto para Subestação |  | 3d | 2022-09-13 | 2022-09-15 | 13 | 45d | 0d |
| 40 | 1.1.8.2 | Descrever teste de resistência de isolamento da Subestação |  | 3d | 2022-09-16 | 2022-09-20 | 39 | 45d | 0d |
| 41 | 1.1.8.3 | Descrever teste de relação de transformação da Subestação |  | 3d | 2022-09-21 | 2022-09-23 | 40 | 45d | 0d |
| 42 | 1.1.8.4 | Descrever teste de resistência ôhmica dos enrolamentos da Subestação |  | 3d | 2022-09-26 | 2022-09-28 | 41 | 45d | 0d |
| 43 | 1.1.8.5 | Procedimentos de manutenção do Transformador de Potencial | milestone | 0d | 2022-09-28 | 2022-09-28 | 42 | 45d |  |
| 44 | 1.1.9 | **Descrever procedimentos de manutenção do Transformador a Seco/Óleo** |  | 15d | 2022-09-29 | 2022-10-19 |  | 30d |  |
| 45 | 1.1.9.1 | Descrever verificações gerais do equipameto para Subestação |  | 3d | 2022-09-29 | 2022-10-03 | 32 | 30d | 0d |
| 46 | 1.1.9.2 | Descrever teste de resistência de isolamento da Subestação |  | 3d | 2022-10-04 | 2022-10-06 | 45 | 30d | 0d |
| 47 | 1.1.9.3 | Descrever teste de relação de transformação da Subestação |  | 3d | 2022-10-07 | 2022-10-11 | 46 | 30d | 0d |
| 48 | 1.1.9.4 | Descrever teste de resistência ôhmica dos enrolamentos da Subestação |  | 3d | 2022-10-12 | 2022-10-14 | 47 | 30d | 0d |
| 49 | 1.1.9.5 | Descrever teste de excitação de enrolamento da Subestação |  | 3d | 2022-10-17 | 2022-10-19 | 48 | 30d | 0d |
| 50 | 1.1.9.6 | Procedimentos de manutenção do Transformador a Seco/Óleo | milestone | 0d | 2022-10-19 | 2022-10-19 | 49 | 30d |  |

| ID | WBS | Task | Type | Duration | Start | Finish | Predecessors | Total slack | Free slack |
| --- | --- | --- | --- | --- | --- | --- | --- | --- | --- |
| 51 | 1.1.10 | **Descrever procedimentos de manutenção do Disjuntor** |  | 18d | 2022-09-29 | 2022-10-24 |  | 20d |  |
| 52 | 1.1.10.1 | Descrever verificações gerais do equipameto para Subestação |  | 3d | 2022-09-29 | 2022-10-03 | 32 | 20d | 0d |
| 53 | 1.1.10.2 | Descrever teste de resistência de isolamento da Subestação |  | 3d | 2022-10-04 | 2022-10-06 | 52 | 20d | 0d |
| 54 | 1.1.10.3 | Descrever teste de resistência de contato da Subestação |  | 3d | 2022-10-07 | 2022-10-11 | 53 | 20d | 0d |
| 55 | 1.1.10.4 | Descrever teste de tensão aplicada para Subestação |  | 3d | 2022-10-12 | 2022-10-14 | 54 | 20d | 0d |
| 56 | 1.1.10.5 | Descrever teste de oscilografia da Subestação |  | 3d | 2022-10-17 | 2022-10-19 | 55 | 20d | 0d |
| 57 | 1.1.10.6 | Descrever teste funcionais da Subestação |  | 3d | 2022-10-20 | 2022-10-24 | 56 | 20d | 0d |
| 58 | 1.1.10.7 | Procedimentos de manutenção do Disjuntor | milestone | 0d | 2022-10-24 | 2022-10-24 | 57 | 20d | 0d |
| 59 | 1.1.11 | **Descrever procedimentos de manutenção opcionais** |  | 7d | 2022-10-25 | 2022-11-02 |  | 20d |  |
| 60 | 1.1.11.1 | Descrever procedimentos sobre os testes de fator de potência da isolação |  | 7d | 2022-10-25 | 2022-11-02 | 58 | 20d | 0d |
| 61 | 1.1.11.2 | Descrever procedimentos sobre os testes de saturação |  | 7d | 2022-10-25 | 2022-11-02 | 58 | 20d |  |
| 62 | 1.1.11.3 | Descrever procedimentos sobre os testes de polaridade |  | 7d | 2022-10-25 | 2022-11-02 | 58 | 20d |  |
| 63 | 1.1.11.4 | Descrever procedimentos sobre os testes manutenção em comando mecânico |  | 7d | 2022-10-25 | 2022-11-02 | 58 | 20d |  |
| 64 | 1.1.11.5 | Descrever procedimentos sobre os testes de fator de potência e capacitância da bucha |  | 7d | 2022-10-25 | 2022-11-02 | 58 | 20d |  |
| 65 | 1.1.11.6 | Descrever procedimentos sobre os testes de TC de bucha |  | 7d | 2022-10-25 | 2022-11-02 | 58 | 20d |  |
| 66 | 1.1.11.7 | Descrever procedimentos sobre os testes de desgaste do contato em camera de vácuo |  | 7d | 2022-10-25 | 2022-11-02 | 58 | 20d |  |
| 67 | 1.1.11.8 | Descrever procedimentos sobre os testes de supervisão e controle de SF6 |  | 1d | 2022-10-25 | 2022-10-25 | 58 | 26d |  |
| 68 | 1.1.11.9 | Descrever procedimentos sobre os testes de medição de corrente de fuga |  | 1d | 2022-10-25 | 2022-10-25 | 58 | 26d |  |
| 69 | 1.1.11.10 | Procedimentos de manutenção opcionais | milestone | 0d | 2022-11-02 | 2022-11-02 | 60 | 20d |  |
| 70 | 1.2 | **Roteiros de prática de manutenção da Subestação** |  | 45d | 2022-09-29 | 2022-11-30 |  | 0d |  |
| 71 | 1.2.1 | **Elaborar Roteiro de Pratica Baia 1: Entrada de energia** |  | 14d | 2022-09-29 | 2022-10-18 |  | 17d |  |
| 72 | 1.2.1.1 | Descrever criterios de segurança para realização da pratica |  | 14d | 2022-09-29 | 2022-10-18 | 32 | 31d |  |
| 73 | 1.2.1.2 | Descrever os equipamentos a serem utilizados na pratica |  | 14d | 2022-09-29 | 2022-10-18 | 32 | 31d |  |
| 74 | 1.2.1.3 | Descrever os EPI's a serem utilizados na realização da prática |  | 14d | 2022-09-29 | 2022-10-18 | 32 | 31d |  |
| 75 | 1.2.1.4 | Descrever os procedimentos a serem realizados antes da prática ser realizada |  | 14d | 2022-09-29 | 2022-10-18 | 32 | 31d |  |
| 76 | 1.2.1.5 | Descrever os procedimentos a serem realizados durante a prática |  | 14d | 2022-09-29 | 2022-10-18 | 32 | 31d |  |
| 77 | 1.2.1.6 | Descrever os procedimentos a serem realizados após a prática ser realizada |  | 14d | 2022-09-29 | 2022-10-18 | 32 | 17d | 0d |
| 78 | 1.2.1.7 | Roteiro de Prática Baia 1 | milestone | 0d | 2022-10-18 | 2022-10-18 | 77 | 17d | 0d |

| ID | WBS | Task | Type | Duration | Start | Finish | Predecessors | Total slack | Free slack |
| --- | --- | --- | --- | --- | --- | --- | --- | --- | --- |
| 79 | 1.2.2 | **Elaborar Roteiro de Pratica Baía 2: Medição de corrente e Medição de Potencial** |  | 14d | 2022-10-19 | 2022-11-07 |  | 17d |  |
| 80 | 1.2.2.1 | Descrever criterios de segurança para realização da pratica |  | 14d | 2022-10-19 | 2022-11-07 | 78 | 17d |  |
| 81 | 1.2.2.2 | Descrever os equipamentos a serem utilizados na pratica |  | 14d | 2022-10-19 | 2022-11-07 | 78 | 17d |  |
| 82 | 1.2.2.3 | Descrever os EPI's a serem utilizados na realização da prática |  | 14d | 2022-10-19 | 2022-11-07 | 78 | 17d |  |
| 83 | 1.2.2.4 | Descrever os procedimentos a serem realizados antes da prática ser realizada |  | 14d | 2022-10-19 | 2022-11-07 | 78 | 17d |  |
| 84 | 1.2.2.5 | Descrever os procedimentos a serem realizados durante a prática |  | 14d | 2022-10-19 | 2022-11-07 | 78 | 17d |  |
| 85 | 1.2.2.6 | Descrever os procedimentos a serem realizados após a prática ser realizada |  | 14d | 2022-10-19 | 2022-11-07 | 78 | 17d | 0d |
| 86 | 1.2.2.7 | Roteiro de Prática Baia 2 | milestone | 0d | 2022-11-07 | 2022-11-07 | 85 | 17d |  |
| 87 | 1.2.3 | **Elaborar Roteiro de Pratica Baía 3:Proteção** |  | 14d | 2022-10-24 | 2022-11-10 |  | 0d |  |
| 88 | 1.2.3.1 | Descrever criterios de segurança para realização da pratica |  | 14d | 2022-10-24 | 2022-11-10 | 123 | 14d |  |
| 89 | 1.2.3.2 | Descrever os equipamentos a serem utilizados na pratica |  | 14d | 2022-10-24 | 2022-11-10 | 123 | 14d |  |
| 90 | 1.2.3.3 | Descrever os EPI's a serem utilizados na realização da prática |  | 14d | 2022-10-24 | 2022-11-10 | 123 | 14d |  |
| 91 | 1.2.3.4 | Descrever os procedimentos a serem realizados antes da prática ser realizada |  | 14d | 2022-10-24 | 2022-11-10 | 123 | 14d |  |
| 92 | 1.2.3.5 | Descrever os procedimentos a serem realizados durante a prática |  | 14d | 2022-10-24 | 2022-11-10 | 123 | 14d |  |
| 93 | 1.2.3.6 | Descrever os procedimentos a serem realizados após a prática ser realizada |  | 14d | 2022-10-24 | 2022-11-10 | 123 | 0d |  |
| 94 | 1.2.3.7 | Roteiro de Prática Baia 3 | milestone | 0d | 2022-11-10 | 2022-11-10 | 93 | 0d |  |
| 95 | 1.2.4 | **Elaborar Roteiro de Pratica Baía 4: Transformação de tensão** |  | 14d | 2022-11-11 | 2022-11-30 |  | 0d |  |
| 96 | 1.2.4.1 | Descrever criterios de segurança para realização da pratica |  | 14d | 2022-11-11 | 2022-11-30 | 94 | 0d |  |
| 97 | 1.2.4.2 | Descrever os equipamentos a serem utilizados na pratica |  | 14d | 2022-11-11 | 2022-11-30 | 94 | 0d |  |
| 98 | 1.2.4.3 | Descrever os EPI's a serem utilizados na realização da prática |  | 14d | 2022-11-11 | 2022-11-30 | 94 | 0d |  |
| 99 | 1.2.4.4 | Descrever os procedimentos a serem realizados antes da prática ser realizada |  | 14d | 2022-11-11 | 2022-11-30 | 94 | 0d |  |
| 100 | 1.2.4.5 | Descrever os procedimentos a serem realizados durante a prática |  | 14d | 2022-11-11 | 2022-11-30 | 94 | 0d |  |
| 101 | 1.2.4.6 | Descrever os procedimentos a serem realizados após a prática ser realizada |  | 14d | 2022-11-11 | 2022-11-30 | 94 | 0d |  |
| 102 | 1.2.4.7 | Roteiro de Prática Baia 4 | milestone | 0d | 2022-11-30 | 2022-11-30 | 101 | 0d |  |

| ID | WBS | Task | Type | Duration | Start | Finish | Predecessors | Total slack |
| --- | --- | --- | --- | --- | --- | --- | --- | --- |
| 103 | 1.3 | **Relatório de alteração de instalação dos equipamentos da subestação (Comparativo com Norma)** |  | 60d | 2022-08-01 | 2022-10-21 |  | 0d |
| 104 | 1.3.1 | **Elaborar Relatório de alteração de instalação da Chave Seccionadora** |  | 12d | 2022-08-01 | 2022-08-16 |  | 0d |
| 105 | 1.3.1.1 | Descrever operação em tensão 34,5KV |  | 12d | 2022-08-01 | 2022-08-16 |  | 76d |
| 106 | 1.3.1.2 | Descrever operação em tensão 380 V |  | 12d | 2022-08-01 | 2022-08-16 |  | 0d |
| 107 | 1.3.1.3 | Relatório de alteração de instalação da Chave Seccionadora | milestone | 0d | 2022-08-16 | 2022-08-16 | 106 | 0d |
| 108 | 1.3.2 | **Elaborar Relatório de alteração de instalação do Transformador de Corrente (TC)** |  | 12d | 2022-08-17 | 2022-09-01 |  | 0d |
| 109 | 1.3.2.1 | Descrever operação em tensão 34,5KV |  | 12d | 2022-08-17 | 2022-09-01 | 107 | 64d |
| 110 | 1.3.2.2 | Descrever operação em tensão 380 V |  | 12d | 2022-08-17 | 2022-09-01 | 107 | 0d |
| 111 | 1.3.2.3 | Relatório de alteração de instalação do Transformador de Corrente | milestone | 0d | 2022-09-01 | 2022-09-01 | 110 | 0d |
| 112 | 1.3.3 | **Elaborar Relatório de alteração de instalação do Transformador de Potencial (TP)** |  | 12d | 2022-09-02 | 2022-09-19 |  | 0d |
| 113 | 1.3.3.1 | Descrever operação em tensão 34,5KV |  | 12d | 2022-09-02 | 2022-09-19 | 111 | 52d |
| 114 | 1.3.3.2 | Descrever operação em tensão 380 V |  | 12d | 2022-09-02 | 2022-09-19 | 111 | 0d |
| 115 | 1.3.3.3 | Relatório de alteração de instalação do Transformador de Potencia | milestone | 0d | 2022-09-19 | 2022-09-19 | 114 | 0d |
| 116 | 1.3.4 | **Elaborar Relatório de alteração de instalação do Transformador a Óleo** |  | 12d | 2022-09-20 | 2022-10-05 |  | 0d |
| 117 | 1.3.4.1 | Descrever operação em tensão 34,5KV |  | 12d | 2022-09-20 | 2022-10-05 | 115 | 40d |
| 118 | 1.3.4.2 | Descrever operação em tensão 380 V |  | 12d | 2022-09-20 | 2022-10-05 | 115 | 0d |
| 119 | 1.3.4.3 | Relatório de alteração de instalação do Transformador a Óleo | milestone | 0d | 2022-10-05 | 2022-10-05 | 118 | 0d |
| 120 | 1.3.5 | **Elaborar Relatório de alteração de instalação do Disjuntor** |  | 12d | 2022-10-06 | 2022-10-21 |  | 0d |
| 121 | 1.3.5.1 | Descrever operação em tensão 34,5KV |  | 12d | 2022-10-06 | 2022-10-21 | 119 | 28d |
| 122 | 1.3.5.2 | Descrever operação em tensão 380 V |  | 12d | 2022-10-06 | 2022-10-21 | 119 | 0d |
| 123 | 1.3.5.3 | Relatório de alteração de instalação do Disjuntor | milestone | 0d | 2022-10-21 | 2022-10-21 | 122 | 0d |
